# Apartments6.mpp

Schedule from MS Project, 2001-05-21 to 2001-10-15, costs in $.
Course Technology

## Calendars

- Standard: Mon-Fri 08:00-12:00, 13:00-17:00; Sat-Sun off.

## Resources

| Resource | Unit | Rate |
| --- | --- | --- |
| Demolition Sub |  |  |
| Framing Sub |  |  |
| Roofing Sub |  |  |
| Masonry Sub |  |  |
| Plumbing Sub |  |  |
| City Inspector |  |  |
| Concrete Sub |  |  |
| HVAC Sub |  |  |
| Fire Protection Sub |  |  |
| Electrical Sub |  |  |
| Superintendent |  | 30 |
| Laborer |  | 15 |
| Carpenter |  | 26 |
| Storage Trailer |  | 1.25 |
| Warehouse |  | 9.23 |
| Site Vehicles |  | 4.52 |
| Field Office Overhead |  | 1.61 |
| Finish Carpentry Sub |  |  |
| Insulation Sub |  |  |
| Drywall Sub |  |  |
| Painting Sub |  |  |
| Flooring Sub |  |  |
| Site Concrete Sub |  |  |
| Fencing Sub |  |  |
| Site Demolition Sub |  |  |
| Asphalt Sub |  |  |
| Grading & Excavating Sub |  |  |
| Metal Stair Manufacturer |  |  |
| Site Plumbing Sub |  |  |
| Gas Utility |  |  |
| Electric Utility |  |  |
| Metal Stairs | EACH | 100000 |
| Metal Stair Installer |  |  |
| Landscaping Sub |  |  |
| Owner |  |  |
| Maid & Cleaning Service |  |  |

## Schedule

| ID | WBS | Task | Type | Duration | Start | Finish | Predecessors | Total slack | Free slack | Constraint | Resources | Work | Cost |
| --- | --- | --- | --- | --- | --- | --- | --- | --- | --- | --- | --- | --- | --- |
| 1 | 1 | Notice To Proceed | milestone | 0d | 2001-05-21 | 2001-05-21 |  | 0d |  | start no earlier than 2001-05-21 | Owner |  |  |
| 2 | 2 | General Conditions |  | 106d | 2001-05-21 | 2001-10-15 | 1, 76FF, 77FF | 0d |  | must start on 2001-05-21 | Superintendent; Laborer [200%]; Storage Trailer [200%]; Warehouse; Site Vehicles [200%]; Field Office Overhead | 7632h | 69,859.05 |
| 3 | 3 | **Interiors Remodeling & Related Exterior Work, 8 Apt. Units** |  | 96d | 2001-06-04 | 2001-10-15 | 1FS+10d | 0d |  |  |  | 2912h | 1,370,998 |
| 4 | 3.1 | Interior Demolition |  | 1d | 2001-06-04 | 2001-06-04 |  | 0d |  |  | Demolition Sub | 8h | 110,000 |
| 5 | 3.2 | Replace Fascia and Soffit |  | 3d | 2001-06-05 | 2001-06-07 | 4 | 89d | 0d |  | Framing Sub | 24h | 6,000 |
| 6 | 3.3 | Roofing |  | 3d | 2001-06-08 | 2001-06-12 | 5 | 89d |  |  | Roofing Sub | 24h | 25,000 |
| 7 | 3.4 | **Interiors Rough-In** |  | 52d | 2001-06-05 | 2001-08-15 |  | 0d |  |  |  | 712h | 818,350 |
| 8 | 3.4.1 | Cut and Infill Masonry per Plans |  | 1d | 2001-06-05 | 2001-06-05 | 4 | 0d |  |  | Masonry Sub | 8h | 7,400 |
| 9 | 3.4.2 | Trench Out Concrete Slab per Plans |  | 1d | 2001-06-06 | 2001-06-06 | 8 | 0d |  |  | Demolition Sub | 8h | 2,200 |
| 10 | 3.4.3 | Rough Plumbing below grade |  | 2d | 2001-06-07 | 2001-06-08 | 9 | 0d |  |  | Plumbing Sub | 16h | 10,000 |
| 11 | 3.4.4 | City Inspection of Rough Plumbing below grade |  | 1d | 2001-06-11 | 2001-06-11 | 10 | 0d |  |  | City Inspector | 8h |  |
| 12 | 3.4.5 | Infill Conrete |  | 1d | 2001-06-12 | 2001-06-12 | 11 | 0d |  |  | Concrete Sub | 8h | 1,250 |
| 13 | 3.4.6 | Rough Framing |  | 20d | 2001-06-13 | 2001-07-10 | 12 | 0d |  |  | Framing Sub | 160h | 375,000 |
| 14 | 3.4.7 | Rough-In Mechanical (Ducting, etc.) |  | 15d | 2001-07-11 | 2001-07-31 | 13 | 0d |  |  | HVAC Sub | 120h | 125,000 |
| 15 | 3.4.8 | Rough-In Plumbing |  | 15d | 2001-07-18 | 2001-08-07 | 14SS+5d | 0d |  |  | Plumbing Sub | 120h | 123,000 |
| 16 | 3.4.9 | Rough-In Fire Sprinkler |  | 15d | 2001-07-18 | 2001-08-07 | 14SS+5d | 0d |  |  | Fire Protection Sub | 120h | 64,000 |
| 17 | 3.4.10 | Rough-In Electrical and Fire Alarm Wiring & Devices |  | 10d | 2001-07-25 | 2001-08-07 | 14SS+10d | 0d |  |  | Electrical Sub | 80h | 89,000 |
| 18 | 3.4.11 | Firestop |  | 2d | 2001-08-08 | 2001-08-09 | 14, 15, 16, 17 | 3d |  |  | Framing Sub | 16h | 9,000 |
| 19 | 3.4.12 | City Inspection of Rough-In Mech/Electrical/Plumbing |  | 1d | 2001-08-08 | 2001-08-08 | 17, 14, 15, 16 | 0d |  |  | City Inspector | 8h |  |
| 20 | 3.4.13 | Frame Soffit Areas |  | 4d | 2001-08-09 | 2001-08-14 | 19 | 0d |  |  | Framing Sub | 32h | 12,500 |
| 21 | 3.4.14 | City Inspection Of Rough Framing |  | 1d | 2001-08-15 | 2001-08-15 | 13, 18, 20 | 0d |  |  | City Inspector | 8h |  |
| 22 | 3.5 | **Interior Finish Work** |  | 34d | 2001-08-14 | 2001-09-28 |  | 0d |  |  |  | 584h | 409,648 |
| 23 | 3.5.1 | Install Windows and Exterior Doors |  | 2d | 2001-08-14 | 2001-08-16 | 24SF, 13 | 27d | 0d |  | Finish Carpentry Sub | 16h | 46,000 |
| 24 | 3.5.2 | Install Insulation |  | 4d | 2001-08-16 | 2001-08-21 | 7 | 0d |  |  | Insulation Sub | 32h | 24,600 |
| 25 | 3.5.3 | Hang Drywall |  | 8d | 2001-08-22 | 2001-08-31 | 24 | 0d |  |  | Drywall Sub | 64h | 75,000 |
| 26 | 3.5.4 | Finish & Texture Drywall |  | 10d | 2001-08-28 | 2001-09-10 | 25SS+4d | 0d |  |  | Drywall Sub | 80h | 60,000 |
| 27 | 3.5.5 | Paint |  | 4d | 2001-09-04 | 2001-09-07 | 26SS+5d | 0d |  |  | Painting Sub | 32h | 15,000 |
| 28 | 3.5.6 | Install Underlayment |  | 3d | 2001-09-06 | 2001-09-10 | 27SS+2d | 1d | 0d |  | Carpenter | 24h | 624 |
| 29 | 3.5.7 | Install Electrical Fixtures |  | 4d | 2001-09-10 | 2001-09-13 | 27 | 0d |  |  | Electrical Sub | 32h | 25,000 |
| 30 | 3.5.8 | Install Water Heaters |  | 2d | 2001-09-11 | 2001-09-12 | 28 | 1d |  |  | Plumbing Sub | 16h | 3,600 |
| 31 | 3.5.9 | Install Furnaces and final sheet metal plenums |  | 3d | 2001-08-16 | 2001-08-20 | 23 | 27d | 15d |  | HVAC Sub | 24h | 17,000 |
| 32 | 3.5.10 | Affix Sprinkler Heads |  | 1d | 2001-09-10 | 2001-09-10 | 27 | 12d | 0d |  | Fire Protection Sub | 8h | 3,400 |
| 33 | 3.5.11 | Activate HVAC and Fire Protection System |  | 2d | 2001-09-11 | 2001-09-12 | 31, 32, 60 | 12d |  |  | HVAC Sub; Fire Protection Sub | 32h | 2,000 |
| 34 | 3.5.12 | Install Flooring |  | 8d | 2001-09-14 | 2001-09-25 | 28, 29, 30 | 0d |  |  | Flooring Sub | 64h | 40,000 |
| 35 | 3.5.13 | Finish Carpentry (Install Cabinets & Interior Doors) |  | 8d | 2001-09-18 | 2001-09-27 | 34SS+2d | 0d |  |  | Finish Carpentry Sub | 64h | 64,000 |
| 36 | 3.5.14 | Install Wood Base and Handrails |  | 4d | 2001-09-24 | 2001-09-27 | 35SS+2d, 37FF+1d | 1d |  |  | Finish Carpentry Sub | 32h | 7,800 |
| 37 | 3.5.15 | Affix Duct Registers |  | 1d | 2001-09-26 | 2001-09-26 | 27, 28, 34 | 1d | 0d |  | HVAC Sub | 8h | 1,000 |
| 38 | 3.5.16 | Accessories and Blinds |  | 3d | 2001-09-18 | 2001-09-20 | 35SS | 6d |  |  | Carpenter | 24h | 624 |
| 39 | 3.5.17 | Plumbing Fixtures |  | 4d | 2001-09-25 | 2001-09-28 | 35FF+1d | 0d |  |  | Plumbing Sub | 32h | 24,000 |
| 40 | 3.6 | City Inspections of Finished Product |  | 1d | 2001-10-01 | 2001-10-01 | 22 | 0d |  |  | City Inspector | 8h |  |
| 41 | 3.7 | Correct any City Punchlist Items |  | 3d | 2001-10-02 | 2001-10-04 | 40 | 0d |  |  |  |  |  |
| 42 | 3.8 | City Re-Inspects |  | 1d | 2001-10-05 | 2001-10-05 | 41 | 0d |  |  | City Inspector | 8h |  |
| 43 | 3.9 | Final Cleaning and Preparation for Turnover |  | 5d | 2001-10-08 | 2001-10-12 | 42 | 0d |  |  | Maid & Cleaning Service | 40h | 2,000 |
| 44 | 3.10 | Turn building over to Owner |  | 1d | 2001-10-15 | 2001-10-15 | 43 | 0d |  |  |  |  |  |

| ID | WBS | Task | Type | Duration | Start | Finish | Predecessors | Total slack | Free slack | Constraint | Resources | Work | Cost |
| --- | --- | --- | --- | --- | --- | --- | --- | --- | --- | --- | --- | --- | --- |
| 45 | 4 | **Site Work and Primary Exterior Work** |  | 89d | 2001-06-04 | 2001-10-04 |  | 7d | 0d |  |  | 3008h | 323,948 |
| 46 | 4.1 | Pour Fence Foundations |  | 1d | 2001-06-04 | 2001-06-04 | 4SS | 7d | 0d |  | Site Concrete Sub | 8h | 15,000 |
| 47 | 4.2 | Fence Posts Masonry |  | 8d | 2001-06-05 | 2001-06-14 | 46 | 7d | 0d |  | Masonry Sub | 64h | 22,000 |
| 48 | 4.3 | Install Iron Fencing |  | 80d | 2001-06-15 | 2001-10-04 | 47 | 7d |  |  | Fencing Sub | 640h | 36,000 |
| 49 | 4.4 | Existing Parking Lot Demolition |  | 5d | 2001-06-04 | 2001-06-08 | 4SS | 84d | 0d |  | Site Demolition Sub | 40h | 11,500 |
| 50 | 4.5 | Install Parking Lot Curbs |  | 5d | 2001-06-11 | 2001-06-15 | 49 | 84d | 0d |  | Site Concrete Sub | 40h | 6,000 |
| 51 | 4.6 | Parking Lot Asphalt |  | 2d | 2001-06-18 | 2001-06-19 | 50 | 84d |  |  | Asphalt Sub | 16h | 12,000 |
| 52 | 4.7 | **Exterior Work** |  | 51d | 2001-06-04 | 2001-08-13 |  | 45d |  |  |  | 960h | 162,140 |
| 53 | 4.7.1 | Locate and Disconnect Utilities |  | 0.5d | 2001-06-04 | 2001-06-04 | 4SS | 48.5d | 0d |  | Gas Utility; Electric Utility | 8h | 500 |
| 54 | 4.7.2 | Selective Demolition per Plans |  | 1d | 2001-06-04 | 2001-06-05 | 53 | 48.5d | 0d |  | Site Demolition Sub | 8h | 6,500 |
| 55 | 4.7.3 | Establish Initial Rough Grade |  | 2d | 2001-06-05 | 2001-06-07 | 54 | 48.5d | 0d |  | Grading & Excavating Sub | 16h | 6,000 |
| 56 | 4.7.4 | Stair Foundations |  | 3d | 2001-06-07 | 2001-06-12 | 55 | 48.5d | 0d |  | Site Concrete Sub | 24h | 5,600 |
| 57 | 4.7.5 | Field Measure Actual Conditions for Building & Stair Foundations |  | 1d | 2001-06-12 | 2001-06-13 | 56 | 48.5d | 0d |  |  |  |  |
| 58 | 4.7.6 | Fabricate Metal Stairs to match Field Conditions |  | 10d | 2001-06-13 | 2001-06-27 | 57 | 48.5d | 0d |  | Metal Stair Manufacturer; Metal Stairs [1 EACH] | 80h | 100,000 |
| 59 | 4.7.7 | **Utilities to Building from Street** |  | 44.5d | 2001-06-12 | 2001-08-13 |  | 25d |  |  |  | 80h | 29,000 |
| 60 | 4.7.7.1 | Fire Service Lines |  | 5d | 2001-06-12 | 2001-06-19 | 56 | 64.5d | 39.5d |  | Site Plumbing Sub | 40h | 24,000 |
| 61 | 4.7.7.2 | Gas Service (by local Utility Company) |  | 3d | 2001-08-09 | 2001-08-13 | 19 | 25d | 0d |  | Gas Utility | 24h | 3,000 |
| 62 | 4.7.7.3 | Electrical Service (by local Electrical Company) |  | 2d | 2001-08-09 | 2001-08-10 | 19 | 26d | 1d |  | Electric Utility | 16h | 2,000 |
| 63 | 4.7.8 | Erect Metal Stairs in place |  | 10d | 2001-06-27 | 2001-07-11 | 8, 58 | 48.5d | 0d |  | Metal Stair Installer | 80h | 12,000 |
| 64 | 4.7.9 | Wood Decking for Stairs |  | 5d | 2001-07-11 | 2001-07-18 | 63 | 61.5d | 0d |  | Carpenter | 40h | 1,040 |
| 65 | 4.7.10 | Paint Stairs |  | 2d | 2001-07-18 | 2001-07-20 | 64 | 61.5d |  |  | Painting Sub | 16h | 1,500 |
| 66 | 4.8 | **Common Area Courtyard** |  | 20d | 2001-08-14 | 2001-09-10 |  | 25d |  |  |  | 208h | 59,308 |
| 67 | 4.8.1 | Re-establish Rough Grade |  | 5d | 2001-08-14 | 2001-08-20 | 60, 61, 62, 63 | 25d | 0d |  | Grading & Excavating Sub | 40h | 6,000 |
| 68 | 4.8.2 | Pour Foundations for Bus Shelters |  | 3d | 2001-08-14 | 2001-08-16 | 67SS | 39d | 0d |  | Site Concrete Sub | 24h | 7,800 |
| 69 | 4.8.3 | Form & Pour Sidewalks |  | 5d | 2001-08-21 | 2001-08-27 | 67 | 25d | 0d |  | Site Concrete Sub | 40h | 16,500 |
| 70 | 4.8.4 | Masonry for Bus Shelters |  | 2d | 2001-08-17 | 2001-08-20 | 68 | 39d | 0d |  | Masonry Sub | 16h | 8,900 |
| 71 | 4.8.5 | Roof Framing and Roofing for Shelters |  | 1d | 2001-08-21 | 2001-08-21 | 70 | 39d |  |  | Roofing Sub | 8h | 900 |
| 72 | 4.8.6 | Final Grading |  | 2d | 2001-08-28 | 2001-08-29 | 69 | 25d | 0d |  | Grading & Excavating Sub | 16h | 3,000 |
| 73 | 4.8.7 | Plant Trees and Shrubs |  | 5d | 2001-08-30 | 2001-09-05 | 72 | 25d | 0d |  | Landscaping Sub | 40h | 10,000 |
| 74 | 4.8.8 | Sod and Seed areas per Plans |  | 2d | 2001-09-06 | 2001-09-07 | 73 | 25d | 0d |  | Landscaping Sub | 16h | 6,000 |
| 75 | 4.8.9 | Set up Site Furniture |  | 1d | 2001-09-10 | 2001-09-10 | 74 | 25d |  |  | Carpenter | 8h | 208 |
| 76 | 5 | All Interior and Exterior Building-related Work Complete | milestone | 0d | 2001-10-15 | 2001-10-15 | 3, 52 | 0d |  |  | Superintendent |  |  |
| 77 | 6 | All Site Work complete | milestone | 0d | 2001-10-04 | 2001-10-04 | 45 | 7d |  |  | Superintendent |  |  |
| 78 | 7 | Required Contract Completion Date | milestone | 0d | 2001-10-15 | 2001-10-15 | 76, 77 | 0d |  | finish no later than 2001-10-15 |  |  |  |
